# Cartridge Filter

Schedule from Primavera P6, 2024-02-10 to 2024-10-06, data date 2024-02-10, costs in USD.

## Calendars

- 7 Day Workweek: Mon-Sun 08:00-16:00.

## Resources

| Resource | Group | Rate |
| --- | --- | --- |
| Weight factor | labor | 1 |

## Schedule

| ID | WBS | Activity | Type | Duration | Start | Finish | Predecessors | Total float | Free float | Resources | Cost |
| --- | --- | --- | --- | --- | --- | --- | --- | --- | --- | --- | --- |
|  | 1 | **Milestone** |  |  | 2024-02-10 | 2024-10-06 |  |  |  |  |  |
| A1000 |  | Start | milestone | 0d | 2024-02-10 | 2024-02-10 |  | 0d |  |  |  |
| A1010 |  | Advance Payment | milestone | 0d | 2024-02-10 | 2024-02-10 | A1000 SS | 0d |  |  |  |
| A1020 |  | Finish | milestone | 0d | 2024-10-06 | 2024-10-06 | A1090 FF, A1830 FF | 0d |  |  |  |
|  | 2 | **Engineering** |  |  | 2024-02-10 | 2024-09-19 |  |  |  |  |  |
|  | 1 | **General** |  |  | 2024-02-10 | 2024-09-19 |  |  |  |  |  |
| A1030 |  | Vendor Print Index and Schedule (VPIS) for Cartridge Filter |  | 15d | 2024-02-10 | 2024-02-24 | A1010 SS | 0d |  | Weight factor [0.2 h] | 0.2 |
| A1050 |  | Project Time Schedule for Cartridge Filter |  | 12d | 2024-02-27 | 2024-03-09 | A1030 FS+2d | 167d | 150d | Weight factor [0.16 h] | 0.16 |
| A1040 |  | Sub Vendor List for Cartridge Filter |  | 12d | 2024-03-16 | 2024-03-27 | A1160 | 28d | 18d | Weight factor [0.16 h] | 0.16 |
| A1060 |  | Commissioning Spare Part List for Cartridge Filter |  | 14d | 2024-06-04 | 2024-06-17 | A1500 | 67d | 50d | Weight factor [0.08 h] | 0.08 |
| A1070 |  | Two Years Operation Spare Parts List for Cartridge Filter |  | 14d | 2024-06-04 | 2024-06-17 | A1500 | 67d | 50d | Weight factor [0.08 h] | 0.08 |
| A1080 |  | Final Book Index for Cartridge Filter |  | 14d | 2024-08-07 | 2024-08-20 | A1160, A1170, A1210, A1190, A1230, A1240, A1250, A1260, A1270, A1280, A1330, A1290, A1300, A1320, A1310, A1340, A1100, A1120, A1110, A1130, A1050, A1060, A1070, A1030, A1040, A1140, A1150 | 17d | 0d | Weight factor [0.04 h] | 0.04 |
| A1090 |  | Final Book for Cartridge Filter |  | 30d | 2024-08-21 | 2024-09-19 | A1080 | 17d |  | Weight factor [0.08 h] | 0.08 |
|  | 2 | **Quality Control** |  |  | 2024-03-16 | 2024-05-08 |  |  |  |  |  |
| A1100 |  | Inspection And Test Plan for Cartridge Filter |  | 14d | 2024-03-16 | 2024-03-29 | A1160 | 133d | 0d | Weight factor [0.17 h] | 0.17 |
| A1120 |  | Preservation , Packaging, And Shipping Procedure for Cartridge Filter |  | 14d | 2024-03-30 | 2024-04-12 | A1100 | 133d | 116d | Weight factor [0.1 h] | 0.1 |
| A1110 |  | Welding Procedure Specification & Qualification Records for Cartridge Filter |  | 14d | 2024-04-25 | 2024-05-08 | A1230, A1160 | 107d | 90d | Weight factor [0.1 h] | 0.1 |
| A1130 |  | Test Procedures for Cartridge Filter |  | 14d | 2024-04-25 | 2024-05-08 | A1230, A1160 | 107d | 90d | Weight factor [0.12 h] | 0.12 |
|  | 3 | **Process** |  |  | 2024-02-15 | 2024-08-06 |  |  |  |  |  |
| A1150 |  | PFD for Cartridge Filter |  | 15d | 2024-02-15 | 2024-02-29 | A1030 SS+5d | 0d |  | Weight factor [0.7 h] | 0.7 |
| A1160 |  | P&ID for Cartridge Filter |  | 15d | 2024-03-01 | 2024-03-15 | A1150 | 0d |  | Weight factor [0.7 h] | 0.7 |
| A1170 |  | Process Description for Cartridge Filter |  | 15d | 2024-03-16 | 2024-03-30 | A1160 | 146d | 129d | Weight factor [0.4 h] | 0.4 |
| A1140 |  | Installation, Operating and Maintenance Manual for Cartridge Filter |  | 10d | 2024-07-28 | 2024-08-06 | A1160 FS+60d, A1260 FS+60d | 17d | 0d | Weight factor [0.2 h] | 0.2 |
|  | 4 | **Mechanical** |  |  | 2024-03-16 | 2024-05-08 |  |  |  |  |  |
| A1190 |  | Equipment Data Sheet-Cartridge Filter |  | 13d | 2024-03-16 | 2024-03-28 | A1160 | 0d |  | Weight factor [0.62 h] | 0.62 |
| A1210 |  | Strength Calculation-Cartridge Filter |  | 13d | 2024-03-29 | 2024-04-10 | A1190 | 0d |  | Weight factor [0.62 h] | 0.62 |
| A1230 |  | General Arrangement Drawing-Cartridge Filter |  | 14d | 2024-04-11 | 2024-04-24 | A1210 | 0d |  | Weight factor [0.76 h] | 0.76 |
| A1240 |  | Name Plate Drawing for Cartridge Filter |  | 10d | 2024-04-25 | 2024-05-04 | A1230, A1160 | 111d | 94d | Weight factor [0.12 h] | 0.12 |
| A1250 |  | Ladder & Platform Drawing for Cartridge Filter |  | 14d | 2024-04-25 | 2024-05-08 | A1230, A1160 | 1d | 0d | Weight factor [0.38 h] | 0.38 |

| ID | WBS | Activity | Duration | Start | Finish | Predecessors | Total float | Free float | Resources | Cost |
| --- | --- | --- | --- | --- | --- | --- | --- | --- | --- | --- |
|  | 5 | **Piping** |  | 2024-05-09 | 2024-06-17 |  |  |  |  |  |
| A1260 |  | GAD For Package for Cartridge Filter | 20d | 2024-05-09 | 2024-05-28 | A1230, A1250, A1160 | 1d | 0d | Weight factor [1.3 h] | 1.3 |
| A1270 |  | MTO for Piping for Cartridge Filter | 20d | 2024-05-29 | 2024-06-17 | A1260 | 1d | 0d | Weight factor [0.7 h] | 0.7 |
|  | 6 | **Instrument** |  | 2024-03-16 | 2024-06-01 |  |  |  |  |  |
| A1280 |  | Instrument List for Cartridge Filter | 15d | 2024-03-16 | 2024-03-30 | A1160 | 67d | 0d | Weight factor [0.3 h] | 0.3 |
| A1300 |  | Junction Boxes Wiring Diagrams And Outline Drawing for Cartridge Filter | 15d | 2024-03-31 | 2024-04-14 | A1280 | 67d | 0d | Weight factor [0.38 h] | 0.38 |
| A1330 |  | Junction Boxes Wiring Diagrams And Outline Drawing | 15d | 2024-04-06 | 2024-04-20 | A1160 FS+21d | 125d | 108d | Weight factor [0.23 h] | 0.23 |
| A1290 |  | I\O List for Cartridge Filter | 15d | 2024-04-07 | 2024-04-21 | A1280 FS+7d | 124d | 107d | Weight factor [0.15 h] | 0.15 |
| A1320 |  | Instrument Cable List for Cartridge Filter | 15d | 2024-04-14 | 2024-04-28 | A1280 FS+14d | 117d | 100d | Weight factor [0.23 h] | 0.23 |
| A1310 |  | Hook Up Drawing for Cartridge Filter | 20d | 2024-05-13 | 2024-06-01 | A1300 FS+28d | 83d | 66d | Weight factor [0.23 h] | 0.23 |
|  | 7 | **Civil** |  | 2024-05-29 | 2024-06-17 |  |  |  |  |  |
| A1340 |  | Foundation Plans With Static/Dynamic Loads, And Bolts Detail for Cartridge Filter | 20d | 2024-05-29 | 2024-06-17 | A1260 | 67d | 50d | Weight factor [0.7 h] | 0.7 |
|  | 3 | **Procurement** |  | 2024-04-15 | 2024-08-11 |  |  |  |  |  |
|  | 1 | **Plate** |  | 2024-04-25 | 2024-05-19 |  |  |  |  |  |
| A1350 |  | Inquiry | 7d | 2024-04-25 | 2024-05-01 | A1230, A1040, A1160 | 0d |  | Weight factor [1.35 h] | 1.35 |
| A1360 |  | P.O (Purchase Order) | 6d | 2024-05-02 | 2024-05-07 | A1350 | 0d |  | Weight factor [5.4 h] | 5.4 |
| A1370 |  | Inspection & Packing | 9d | 2024-05-08 | 2024-05-16 | A1360 | 0d |  | Weight factor [5.4 h] | 5.4 |
| A1380 |  | Delivery to Shop | 3d | 2024-05-17 | 2024-05-19 | A1370 | 0d |  | Weight factor [1.35 h] | 1.35 |
|  | 2 | **Nozzle** |  | 2024-04-25 | 2024-05-26 |  |  |  |  |  |
| A1410 |  | Inquiry | 8d | 2024-04-25 | 2024-05-02 | A1230, A1040, A1160 | 62d | 0d | Weight factor [0.68 h] | 0.68 |
| A1420 |  | P.O (Purchase Order) | 5d | 2024-05-03 | 2024-05-07 | A1410 | 62d | 0d | Weight factor [2.7 h] | 2.7 |
| A1440 |  | Inspection & Packing | 14d | 2024-05-08 | 2024-05-21 | A1420 | 62d | 0d | Weight factor [2.7 h] | 2.7 |
| A1450 |  | Delivery to Shop | 5d | 2024-05-22 | 2024-05-26 | A1440 | 62d |  | Weight factor [0.68 h] | 0.68 |
|  | 3 | **Instrument** |  | 2024-04-15 | 2024-06-03 |  |  |  |  |  |
| A1460 |  | Inquiry | 15d | 2024-04-15 | 2024-04-29 | A1040, A1300 | 67d | 0d | Weight factor [0.95 h] | 0.95 |
| A1470 |  | P.O (Purchase Order) | 5d | 2024-04-30 | 2024-05-04 | A1460 | 67d | 0d | Weight factor [0.95 h] | 0.95 |
| A1480 |  | Manufacturing | 20d | 2024-05-05 | 2024-05-24 | A1470 | 67d | 0d | Weight factor [5.68 h] | 5.68 |
| A1490 |  | Inspection & Packing | 5d | 2024-05-25 | 2024-05-29 | A1480 | 67d | 0d | Weight factor [0.95 h] | 0.95 |
| A1500 |  | Delivery to Shop | 5d | 2024-05-30 | 2024-06-03 | A1490 | 67d | 0d | Weight factor [0.95 h] | 0.95 |

| ID | WBS | Activity | Duration | Start | Finish | Predecessors | Total float | Free float | Resources | Cost |
| --- | --- | --- | --- | --- | --- | --- | --- | --- | --- | --- |
|  | 5 | **Pipe, Fitting & Valve** |  | 2024-06-18 | 2024-08-11 |  |  |  |  |  |
| A1510 |  | Inquiry | 30d | 2024-06-18 | 2024-07-17 | A1040, A1270 | 1d | 0d | Weight factor [1.35 h] | 1.35 |
| A1520 |  | P.O (Purchase Order) | 10d | 2024-07-18 | 2024-07-27 | A1510 | 1d | 0d | Weight factor [5.4 h] | 5.4 |
| A1530 |  | Inspection & Packing | 10d | 2024-07-28 | 2024-08-06 | A1520 | 1d | 0d | Weight factor [5.4 h] | 5.4 |
| A1540 |  | Delivery to Shop | 5d | 2024-08-07 | 2024-08-11 | A1530 | 1d | 0d | Weight factor [1.35 h] | 1.35 |
|  | 4 | **Material for Skid** |  | 2024-05-29 | 2024-06-22 |  |  |  |  |  |
| A1750 |  | Inquiry | 7d | 2024-05-29 | 2024-06-04 | A1260, A1040 | 32d | 0d | Weight factor [0.68 h] | 0.68 |
| A1760 |  | P.O (Purchase Order) | 6d | 2024-06-05 | 2024-06-10 | A1750 | 32d | 0d | Weight factor [2.7 h] | 2.7 |
| A1770 |  | Inspection & Packing | 9d | 2024-06-11 | 2024-06-19 | A1760 | 32d | 0d | Weight factor [2.7 h] | 2.7 |
| A1780 |  | Delivery to Shop | 3d | 2024-06-20 | 2024-06-22 | A1770 | 32d | 0d | Weight factor [0.68 h] | 0.68 |
|  | 4 | **Fabrication** |  | 2024-05-20 | 2024-09-16 |  |  |  |  |  |
|  | 1 | **Cartridge Filter** |  | 2024-05-20 | 2024-09-16 |  |  |  |  |  |
|  | 1 | **Pressure Vessel & Ladder Platform** |  | 2024-05-20 | 2024-09-16 |  |  |  |  |  |
| A1600 |  | Cutting | 10d | 2024-05-20 | 2024-05-29 | A1380 | 0d |  | Weight factor [0.97 h] | 0.97 |
| A1610 |  | Head Fabrication | 20d | 2024-05-30 | 2024-06-18 | A1600 | 0d |  | Weight factor [2.92 h] | 2.92 |
| A1620 |  | Shell Fitup | 14d | 2024-06-19 | 2024-07-02 | A1610 | 0d |  | Weight factor [0.97 h] | 0.97 |
| A1630 |  | Shell Welding | 25d | 2024-07-03 | 2024-07-27 | A1620 | 0d |  | Weight factor [5.85 h] | 5.85 |
| A1640 |  | Nozzle opening & Fitup | 10d | 2024-07-28 | 2024-08-06 | A1630, A1450 | 0d |  | Weight factor [0.97 h] | 0.97 |
| A1650 |  | Nozzle Welding | 20d | 2024-08-07 | 2024-08-26 | A1640 | 0d |  | Weight factor [2.92 h] | 2.92 |
| A1660 |  | NDT | 9d | 2024-08-27 | 2024-09-04 | A1650 | 0d |  | Weight factor [1.95 h] | 1.95 |
| A1680 |  | Hydrostatic Test | 5d | 2024-09-05 | 2024-09-09 | A1660 | 0d |  | Weight factor [1.95 h] | 1.95 |
| A1690 |  | Sand Blast & Painting | 7d | 2024-09-10 | 2024-09-16 | A1680 | 0d |  | Weight factor [0.97 h] | 0.97 |
|  | 2 | **Piping Spools** |  | 2024-08-12 | 2024-09-15 |  |  |  |  |  |
| A1700 |  | Cutting & Fitup | 10d | 2024-08-12 | 2024-08-21 | A1540 | 1d | 0d | Weight factor [2.25 h] | 2.25 |
| A1710 |  | Welding | 10d | 2024-08-22 | 2024-08-31 | A1700 | 1d | 0d | Weight factor [3 h] | 3 |
| A1720 |  | NDT | 5d | 2024-09-01 | 2024-09-05 | A1710 | 1d | 0d | Weight factor [0.75 h] | 0.75 |
| A1730 |  | Hydrostatic Test | 5d | 2024-09-06 | 2024-09-10 | A1720 | 1d | 0d | Weight factor [0.75 h] | 0.75 |
| A1740 |  | Sand Blast & Painting | 5d | 2024-09-11 | 2024-09-15 | A1730 | 1d |  | Weight factor [0.75 h] | 0.75 |

| ID | WBS | Activity | Duration | Start | Finish | Predecessors | Total float | Free float | Resources | Cost |
| --- | --- | --- | --- | --- | --- | --- | --- | --- | --- | --- |
|  | 3 | **Skid** |  | 2024-06-23 | 2024-08-15 |  |  |  |  |  |
| A1790 |  | Cutting & Fitup | 15d | 2024-06-23 | 2024-07-07 | A1780 | 32d | 0d | Weight factor [1.05 h] | 1.05 |
| A1800 |  | Welding | 25d | 2024-07-08 | 2024-08-01 | A1790 | 32d | 0d | Weight factor [1.35 h] | 1.35 |
| A1810 |  | NDT | 7d | 2024-08-02 | 2024-08-08 | A1800 | 32d | 0d | Weight factor [0.3 h] | 0.3 |
| A1820 |  | Sand Blast & Painting | 7d | 2024-08-09 | 2024-08-15 | A1810 | 32d |  | Weight factor [0.3 h] | 0.3 |
|  | 5 | **Final Assembly** |  | 2024-09-17 | 2024-09-26 |  |  |  |  |  |
| A1400 |  | Filter Package & Active Carbone Package | 10d | 2024-09-17 | 2024-09-26 | A1820, A1690, A1740, A1500 | 0d |  | Weight factor [5 h] | 5 |
|  | 6 | **Final Inspection & Ex-Work Delivery** |  | 2024-09-27 | 2024-10-06 |  |  |  |  |  |
| A1830 |  | Filter Package & Active Carbone Package | 10d | 2024-09-27 | 2024-10-06 | A1400, A1120, A1130 | 0d |  | Weight factor [5 h] | 5 |
